# Cronograma para el Alcantarillado Sanitario El Romeral

Schedule from MS Project, 2026-07-06 to 2026-09-03, costs in $.

## Calendars

- Calendario Romeral: Mon-Sun 08:00-13:00, 14:00-17:00.

## Resources

| Resource |
| --- |
| Sum/Ins/Tra Sumidero H.S. d=600 mm salida 200 mm4000 |

## Schedule

| ID | WBS | Task | Type | Duration | Start | Finish | Predecessors | Total slack | Cost | Cantidad | P.U | Unidad |
| --- | --- | --- | --- | --- | --- | --- | --- | --- | --- | --- | --- | --- |
| 1 | 1 | **COSTO TOTAL PROYECTO: “MEJORAMIENTO DE LAS REDES DE ALCANTARILLADO PLUVIAL Y SANITARIO BARRIO SIMÓN BOLÍVAR DE LA COOP. MODELO”.** |  | 60d | 2026-07-06 | 2026-09-03 |  | 0d | 81,189.78 |  |  |  |
| 2 | 1.1 | **MEJORAMIENTO DE LAS REDES DE ALCANTARILLADO SANITARIO.** |  | 60d | 2026-07-06 | 2026-09-03 |  |  | 48,500.39 |  |  |  |
| 3 | 1.1.1 | inicio | milestone, manual | 0d | 2026-07-06 | 2026-07-06 |  |  |  |  |  |  |
| 4 | 1.1.2 | Replanteo y nivelación para redes hidrosanitarias. | manual | 45d | 2026-07-06 | 2026-08-19 | 3 |  | 635.05 | 203,92 | 0,50 |  |
| 5 | 1.1.3 | Sum/Ins/Tra Tapa Redonda HD 600mm. | manual | 10d | 2026-08-25 | 2026-09-03 | 19 |  | 3,417.2 |  |  |  |
| 6 | 1.1.4 | Rasanteo y preparación zanja (inc. Cama de arena). | manual | 35d | 2026-07-06 | 2026-08-09 |  |  | 2,600.52 |  |  |  |
| 7 | 1.1.5 | Excavación de suelo natural <2 m (a máquina). | manual | 25d | 2026-07-07 | 2026-07-31 | 3, 4 |  | 2,717.79 | 140,99 | 3,25 | m² |
| 8 | 1.1.6 | Excavación de suelo natural 2 a 4 m (a máquina). | manual | 20d | 2026-07-10 | 2026-07-29 |  |  | 542.99 | 104,21 | 2,35 | m³ |
| 9 | 1.1.7 | Excavación de suelo natural <2m (manual). | manual | 25d | 2026-07-10 | 2026-08-03 |  |  | 763.6 | 163,30 | 2,82 | m³ |
| 10 | 1.1.8 | Desalojo a máquina (dist= 5 km). | manual | 45d | 2026-07-21 | 2026-09-03 | 24 |  | 745.42 | 21,33 | 12,8 | m³ |
| 11 | 1.1.9 | Relleno compactado con material lastre. | manual | 10d | 2026-08-25 | 2026-09-03 |  |  | 2,754.63 | 73,26 | 5,58 | m³ |
| 12 | 1.1.10 | Hormigón Simple en replantillos f`c=140 kg/cm2. | manual | 5d | 2026-07-08 | 2026-07-12 |  |  | 381.92 | 215,57 | 4,08 | m³ |
| 13 | 1.1.11 | Tapa H.A f`c=180 para caja de revisión 0.60x0.60m. | manual | 30d | 2026-08-05 | 2026-09-03 | 9 |  | 2,091 | 46,89 | 2,65 | kg |
| 14 | 1.1.12 | Caja de revisión H.S 0.60x0.60 (el cuerpo). | manual | 30d | 2026-08-05 | 2026-09-03 | 9 |  | 5,076.77 | 0,88 | 162,13 | m³ |
| 15 | 1.1.13 | Base de H.S 0.90x0.90m e=10cm para caja de revisión. | manual | 30d | 2026-08-05 | 2026-09-03 | 9 |  | 1,274.4 | 4,07 | 239,22 | m³ |
| 16 | 1.1.14 | Derrocamiento pozo revisión (recuperando tapa). | manual | 2d | 2026-07-20 | 2026-07-21 |  |  | 21.1 | 11,00 | 34,5 |  |
| 17 | 1.1.15 | Losa de Tapa HA para pozo revisión e=0.20m d=1.40m. | manual | 14d | 2026-08-03 | 2026-08-16 | 20, 21 |  | 1,054.5 | 11,00 | 103,48 |  |
| 18 | 1.1.16 | Base H.C. del pozo de revisión d=1.50m e=0.30m. | manual | 7d | 2026-07-13 | 2026-07-19 | 12 |  | 577.1 | 11,00 | 20,32 |  |
| 19 | 1.1.17 | Sum/Ins/Tra Estribos de pozo de revisión d=16mm. | manual | 6d | 2026-08-17 | 2026-08-22 | 17 |  | 408.94 | 2,00 | 103,99 |  |
| 20 | 1.1.18 | Pozo de Revisión H.S f`c=210kg/cm2 h=0-2m di=1m (el cuerpo). | manual | 14d | 2026-07-20 | 2026-08-02 | 18 |  | 1,987.9 | 2,00 | 54,74 |  |
| 21 | 1.1.19 | Pozo de Revisión H.S f`c=210kg/cm2 h=2-4m di=1m (el cuerpo). | manual | 14d | 2026-07-20 | 2026-08-02 | 18 |  | 448.98 | 8,00 | 8,63 |  |
| 22 | 1.1.20 | Sum/Ins/Tra Tubería PVC para alcantarillado dn=175mm. | manual | 30d | 2026-08-05 | 2026-09-03 | 9 |  | 6,561.4 | 2,00 | 121,41 |  |
| 23 | 1.1.21 | Sum/Ins/Tra Tubería PVC para alcantarillado dn=220mm. | manual | 40d | 2026-07-26 | 2026-09-03 | 7 |  | 10,952.01 | 87,55 | 15,52 |  |
| 24 | 1.1.22 | Relleno compactado con material de excavación. | manual | 45d | 2026-07-21 | 2026-09-03 |  |  | 3,487.17 |  |  |  |
| 25 | 1.1.23 | fin | milestone, manual | 0d | 2026-09-03 | 2026-09-03 | 5, 13 |  |  |  |  |  |

| ID | WBS | Task | Type | Duration | Start | Finish | Predecessors | Cost |
| --- | --- | --- | --- | --- | --- | --- | --- | --- |
| 29 | 1.2 | **MEJORAMIENTO DE LAS REDES DE ALCANTARILLADO PLUVIAL.** |  | 60d | 2026-07-06 | 2026-09-03 |  | 32,689.39 |
| 30 | 1.2.1 | inicio | milestone, manual | 0d | 2026-07-06 | 2026-07-06 |  |  |
| 31 | 1.2.2 | Replanteo y nivelación para redes hidrosanitarias. | manual | 45d | 2026-07-06 | 2026-08-19 | 30 | 230.1 |
| 32 | 1.2.3 | Sum/Ins/Tra Rejilla Sumidero HD 600x300mm. | manual | 15d | 2026-08-20 | 2026-09-03 | 38, 35, 31 | 3,796.8 |
| 33 | 1.2.4 | Sum/Ins/Tra Tapa Conjunto Rejilla HD 600mm. | manual | 15d | 2026-08-20 | 2026-09-03 | 44 | 2,862.58 |
| 34 | 1.2.5 | Rasanteo y preparación zanja (inc. Cama de arena). | manual | 35d | 2026-07-06 | 2026-08-09 |  | 770.71 |
| 35 | 1.2.6 | Sum/Ins/Tra Sumidero H.S. d=600 mm salida 200mm. | manual | 20d | 2026-07-31 | 2026-08-19 |  | 737.76 |
| 36 | 1.2.7 | Excavación de suelo natural <2 m (a máquina). | manual | 25d | 2026-07-07 | 2026-07-31 |  | 1,497.66 |
| 37 | 1.2.8 | Excavación de suelo natural 2 a 4 m (a máquina). | manual | 25d | 2026-07-07 | 2026-07-31 |  | 583.43 |
| 38 | 1.2.9 | Excavación de suelo natural <2m (manual). | manual | 25d | 2026-07-10 | 2026-08-03 |  | 1,143.79 |
| 39 | 1.2.10 | Desalojo a máquina (dist= 5 km). | manual | 45d | 2026-07-21 | 2026-09-03 |  | 444.47 |
| 40 | 1.2.11 | Relleno compactado con material lastre. | manual | 10d | 2026-08-25 | 2026-09-03 |  | 2,772.17 |
| 41 | 1.2.12 | Hormigón Simple en replantillos f`c=140 kg/cm2. | manual | 5d | 2026-07-08 | 2026-07-12 |  | 268.19 |
| 42 | 1.2.13 | Entibado. | manual | 7d | 2026-08-01 | 2026-08-07 | 37 | 619.84 |
| 43 | 1.2.14 | Derrocamiento pozo revisión (recuperando tapa). | manual | 3d | 2026-07-10 | 2026-07-12 |  | 21.1 |
| 44 | 1.2.15 | Losa de Tapa HA para pozo revisión e=0.20m d=1.40m. | manual | 14d | 2026-08-05 | 2026-08-18 | 48, 47 | 738.15 |
| 45 | 1.2.16 | Base H.C. del pozo de revisión d=1.50m e=0.30m. | manual | 8d | 2026-07-13 | 2026-07-20 | 41 | 403.97 |
| 46 | 1.2.17 | Sum/Ins/Tra Estribos de pozo de revisión d=16mm. | manual | 6d | 2026-08-22 | 2026-08-27 | 44 | 320.04 |
| 47 | 1.2.18 | Pozo de Revisión H.S f`c=210kg/cm2 h=0-2m di=1m (el cuerpo). | manual | 14d | 2026-07-21 | 2026-08-03 | 45 | 1,506.78 |
| 48 | 1.2.19 | Pozo de Revisión H.S f`c=210kg/cm2 h=2-4m di=1m (el cuerpo). | manual | 14d | 2026-07-22 | 2026-08-04 |  | 415.73 |
| 49 | 1.2.20 | Sum/Ins/Tra Tubería PVC para alcantarillado dn=220mm. | manual | 30d | 2026-08-01 | 2026-08-30 | 36 | 1,610.87 |
| 50 | 1.2.21 | Sum/Ins/Tra Tubería PVC para alcantarillado dn=280mm. | manual | 40d | 2026-07-26 | 2026-09-03 |  | 5,464.71 |
| 51 | 1.2.22 | Sum/Ins/Tra Tubería PVC para alcantarillado dn=400mm. | manual | 20d | 2026-08-15 | 2026-09-03 | 37 | 4,266.39 |
| 52 | 1.2.23 | Relleno compactado con material de excavación. | manual | 45d | 2026-07-21 | 2026-09-03 |  | 2,214.15 |
| 53 | 1.2.24 | fin | milestone, manual | 0d | 2026-09-03 | 2026-09-03 |  |  |
